# Publicidad Juguetes Wingtip 6

Schedule from MS Project, 2012-01-09 to 2012-02-01, costs in €.
Microsoft

## Calendars

- Estándar: Mon-Fri 09:00-13:00, 15:00-19:00; Sat-Sun off.

## Resources

| Resource | Unit | Rate | Notes |
| --- | --- | --- | --- |
| Jonathan Mollerup |  | 10 |  |
| Jon Ganio |  | 15.5 |  |
| Garrett R. Vargas |  | 20 | Garret ha recibido formación en iluminación y rodaje |
| John Rodman |  | 22 |  |
| Electricista |  | 22 |  |
| Videocámara Mini-DV |  | 6.25 |  |
| Trípode de cámara |  |  |  |
| Laboratorio de edición |  | 25 |  |
| Cinta de vídeo | Cinta de 30 minutos | 5 |  |
| Viajes |  |  |  |
| Foco de 600 watios con soporte |  | 2.5 |  |
| Catering |  |  |  |
| Jim Hance |  | 18.75 |  |
| Scott Cooper |  | 19.37 |  |
| Patti Mintz |  | 9.4 |  |
| Peter Kelly |  | 16.75 |  |
| Jo Brown |  | 18.75 |  |
| Reflector |  |  |  |

## Schedule

| ID | WBS | Task | Type | Duration | Start | Finish | Predecessors | Baseline start | Baseline finish | Baseline duration | Total slack | Resources | Work | Cost | Baseline cost |
| --- | --- | --- | --- | --- | --- | --- | --- | --- | --- | --- | --- | --- | --- | --- | --- |
| 1 | 1 | **Preproducción** |  | 8.5d | 2012-01-09 | 2012-01-19 |  | 2012-01-09 | 2012-01-19 | 8.5d | 0d |  | 168h | 3,169.7 | 3,169.7 |
| 2 | 1.1 | Desarrollo del guión literario |  | 2.5d | 2012-01-09 | 2012-01-11 |  | 2012-01-09 | 2012-01-11 | 2.5d | 0d | Scott Cooper; Patti Mintz | 40h | 575.5 | 575.5 |
| 3 | 1.2 | Desarrollo del guión técnico |  | 3d | 2012-01-11 | 2012-01-16 | 2 | 2012-01-11 | 2012-01-16 | 3d | 0d | Garrett R. Vargas; Patti Mintz | 48h | 705.6 | 705.6 |
| 4 | 1.3 | Localización de exteriores |  | 1d | 2012-01-16 | 2012-01-17 | 3 | 2012-01-16 | 2012-01-17 | 1d | 0d | Scott Cooper; Patti Mintz; Cinta de vídeo [4 Cinta de 30 minutos]; Viajes [0.6%] | 16h | 750.2 | 750.2 |
| 5 | 1.4 | Realización de pruebas a actores |  | 2d | 2012-01-17 | 2012-01-19 | 4 | 2012-01-17 | 2012-01-19 | 2d | 0d | Peter Kelly; Scott Cooper; Jonathan Mollerup; Patti Mintz; Catering [0.2%] | 64h | 1,138.4 | 1,138.4 |
| 6 | 1.5 | ¡Preproducción finalizada! | milestone | 0d | 2012-01-19 | 2012-01-19 | 5 | 2012-01-19 | 2012-01-19 | 0d | 0d |  |  |  |  |
| 7 | 2 | **Producción** |  | 5.25d | 2012-01-19 | 2012-01-26 | 1 | 2012-01-19 | 2012-01-26 | 5.25d | 0d |  | 42h | 515 | 515 |
| 8 | 2.1 | Ensayo |  | 2.25d | 2012-01-19 | 2012-01-23 |  | 2012-01-19 | 2012-01-23 | 2.25d | 0d | Foco de 600 watios con soporte | 18h | 45 | 45 |
| 9 | 2.2 | Rodaje |  | 2d | 2012-01-23 | 2012-01-25 | 8 | 2012-01-23 | 2012-01-25 | 2d | 0d | Garrett R. Vargas | 16h | 320 | 320 |
| 10 | 2.3 | Montaje |  | 1d | 2012-01-25 | 2012-01-26 | 9 | 2012-01-25 | 2012-01-26 | 1d | 0d | Jo Brown | 8h | 150 | 150 |
| 11 | 2.4 | ¡Producción finalizada! | milestone | 0d | 2012-01-26 | 2012-01-26 | 10 | 2012-01-26 | 2012-01-26 | 0d | 0d |  |  |  |  |
| 12 | 3 | **Post-producción** |  | 3.5d | 2012-01-26 | 2012-02-01 | 7 | 2012-01-26 | 2012-02-01 | 3.5d | 0d |  | 16h | 400 | 400 |
| 13 | 3.1 | Ajustes finales |  | 2d | 2012-01-26 | 2012-01-30 |  | 2012-01-26 | 2012-01-30 | 2d | 0d | Laboratorio de edición | 16h | 400 | 400 |
| 14 | 3.2 | Adición banda de audio |  | 1d | 2012-01-30 | 2012-01-31 | 13 | 2012-01-30 | 2012-01-31 | 1d | 0d |  |  |  |  |
| 15 | 3.3 | Entrega a cliente |  | 4h | 2012-01-31 | 2012-02-01 | 14 | 2012-01-31 | 2012-02-01 | 4h | 0d |  |  |  |  |

Notes:
- 4: Incluye escenas exteriores callejeras, así como escenas interiores en estudio.
